# Full Monte Demonstration

Schedule from MS Project, 2023-05-01 to 2023-08-16, status date 2023-05-01, costs in $.
BarbecanaSI:V6/FTF/0/0/60/0/15274793/0/(None)/LOE/(None)/X/(None)/PP/(None)/1/11133507/T0ATF/T0/0/=0%/T0/0/=0%/T0/10/=0%/T0/10/=0%/F0/0/=0%/F0/0/=0%/F0/0/=0%/T0/0/=0%/T4/0/=0%/T4/0/=1/T4/0/=1/T0/0/=0%/T0/0/<5%/T0/0/>90%/T0/0/<5%/T0/22d/<5%/T0/0/=0%/T22/44d/<5%/T0/0/=0%/T4/0/=0%/T12/0/=0%/T0/0/<5%/T37/120w/=0%/T5/0/>0.95/T12/0/>0.95/T0/0/=0%/T0/0/=0%/T0/0/=0%/T0/0/=0%/T0/0/=0%/T23/44d/=0%

## Calendars

- Standard: Mon-Fri 08:00-12:00, 13:00-17:00; Sat-Sun off.

## Resources

| Resource | Rate |
| --- | --- |
| PM | 80 |
| HW Engineer | 50 |
| SW Enginner | 60 |
| MKTG | 30 |
| PRINT |  |
| PAPER | 1.5 |

## Schedule

| ID | WBS | Task | Type | Duration | Start | Finish | Predecessors | Baseline start | Baseline finish | Baseline duration | Baseline 1 start | Baseline 1 finish | Total slack | Free slack | Constraint | Resources | Work | Cost | Baseline cost | Text1 | Text10 |
| --- | --- | --- | --- | --- | --- | --- | --- | --- | --- | --- | --- | --- | --- | --- | --- | --- | --- | --- | --- | --- | --- |
| 1 | 1 | **Sample Project** |  | 78d | 2023-05-01 | 2023-08-16 |  | 2023-05-01 | 2023-08-14 | 76d | 2017-05-01 | 2017-08-04 | 0d |  |  |  | 1400h | 83,680 | 83,680 |  |  |
| 2 | 1.1 | Initiate |  | 5d | 2023-05-01 | 2023-05-05 |  | 2023-05-01 | 2023-05-05 | 5d | 2017-05-01 | 2017-05-05 | 0d |  |  | PM | 40h | 3,200 | 3,200 |  |  |
| 3 | 1.2 | **Development** |  | 60d | 2023-05-08 | 2023-07-28 |  | 2023-05-08 | 2023-07-28 | 60d | 2017-05-08 | 2017-07-28 | 0d |  |  |  | 1200h | 65,680 | 65,680 |  |  |
| 4 | 1.2.1 | **Hardware** |  | 60d | 2023-05-08 | 2023-07-28 |  | 2023-05-08 | 2023-07-28 | 60d | 2017-05-08 | 2017-07-28 | 0d |  |  |  | 632h | 31,600 | 31,600 |  |  |
| 5 | 1.2.1.1 | HW Design |  | 20d | 2023-05-08 | 2023-06-02 | 2 | 2023-05-08 | 2023-06-02 | 20d | 2017-05-08 | 2017-06-02 | 0d |  |  | HW Engineer | 160h | 8,000 | 8,000 |  |  |
| 6 | 1.2.1.2 | HW Part A |  | 20d | 2023-06-05 | 2023-06-30 | 5 | 2023-06-05 | 2023-06-30 | 20d | 2017-06-05 | 2017-06-30 | 0d |  |  | HW Engineer | 160h | 8,000 | 8,000 | RSK002 |  |
| 7 | 1.2.1.3 | HW Part B |  | 19d | 2023-06-05 | 2023-06-29 | 5 | 2023-06-05 | 2023-06-29 | 19d | 2017-06-05 | 2017-06-30 | 1d |  |  | HW Engineer | 152h | 7,600 | 7,600 | RSK002 |  |
| 8 | 1.2.1.4 | HW Integrate |  | 20d | 2023-07-03 | 2023-07-28 | 6, 7 | 2023-07-03 | 2023-07-28 | 20d | 2017-07-03 | 2017-07-28 | 0d |  |  | HW Engineer | 160h | 8,000 | 8,000 |  |  |
| 9 | 1.2.1.5 | HW Complete | milestone | 0d | 2023-07-28 | 2023-07-28 | 8 | 2023-07-28 | 2023-07-28 | 0d | 2017-07-28 | 2017-07-28 | 0d |  |  |  |  |  |  |  |  |
| 10 | 1.2.2 | **Software** |  | 54d | 2023-05-08 | 2023-07-20 |  | 2023-05-08 | 2023-07-20 | 54d | 2017-05-08 | 2017-07-20 | 6d |  |  |  | 568h | 34,080 | 34,080 |  |  |
| 11 | 1.2.2.1 | SW Design |  | 18d | 2023-05-08 | 2023-05-31 | 2 | 2023-05-08 | 2023-05-31 | 18d | 2017-05-08 | 2017-05-31 | 6d | 0d |  | SW Enginner | 144h | 8,640 | 8,640 |  | Triangular |
| 12 | 1.2.2.2 | SW Code A |  | 18d | 2023-06-01 | 2023-06-26 | 11 | 2023-06-01 | 2023-06-26 | 18d | 2017-06-01 | 2017-06-26 | 6d | 0d |  | SW Enginner | 144h | 8,640 | 8,640 | RSK003 | Triangular |
| 13 | 1.2.2.3 | SW Code B |  | 17d | 2023-06-01 | 2023-06-23 | 11 | 2023-06-01 | 2023-06-23 | 17d | 2017-06-01 | 2017-06-26 | 7d | 1d |  | SW Enginner | 136h | 8,160 | 8,160 | RSK003 | Triangular |
| 14 | 1.2.2.4 | SW Integrate |  | 18d | 2023-06-27 | 2023-07-20 | 12, 13 | 2023-06-27 | 2023-07-20 | 18d | 2017-06-27 | 2017-07-20 | 6d | 0d |  | SW Enginner | 144h | 8,640 | 8,640 |  | Triangular |
| 15 | 1.2.2.5 | SW Complete | milestone | 0d | 2023-07-20 | 2023-07-20 | 14 | 2023-07-20 | 2023-07-20 | 0d | 2017-07-20 | 2017-07-20 | 6d |  |  |  |  |  |  |  |  |
| 16 | 1.3 | **Integration** |  | 5d | 2023-07-31 | 2023-08-04 |  | 2023-07-31 | 2023-08-04 | 5d | 2017-07-31 | 2017-08-04 | 0d |  |  |  | 80h | 4,400 | 4,400 |  |  |
| 17 | 1.3.1 | Testing |  | 5d | 2023-07-31 | 2023-08-04 | 9, 15 | 2023-07-31 | 2023-08-04 | 5d | 2017-07-31 | 2017-08-04 | 0d |  |  | HW Engineer; SW Enginner | 80h | 4,400 | 4,400 |  |  |
| 18 | 1.4 | **Marketing** |  | 15d | 2023-07-10 | 2023-07-28 |  | 2023-07-10 | 2023-07-28 | 15d | 2017-07-10 | 2017-07-28 | 5d |  |  |  | 80h | 10,400 | 10,400 |  |  |
| 19 | 1.4.1 | Market Analysis | milestone | 0d | 2023-07-10 | 2023-07-10 |  |  |  |  |  |  | 5d | 0d | start no earlier than 2023-07-10 |  |  |  |  |  | Beta |
| 20 | 1.4.2 | Brochure Design |  | 10d | 2023-07-10 | 2023-07-21 | 19 | 2023-07-10 | 2023-07-21 | 10d | 2017-07-10 | 2017-07-21 | 5d | 0d |  | MKTG | 80h | 2,400 | 2,400 |  |  |
| 21 | 1.4.3 | Brochure Printing |  | 5d | 2023-07-24 | 2023-07-28 | 20 | 2023-07-24 | 2023-07-28 | 5d | 2017-07-24 | 2017-07-28 | 5d |  |  | PRINT [0.1%]; PAPER [500000%] |  | 8,000 | 8,000 |  |  |
| 22 | 1.5 | Work Complete | milestone | 0d | 2023-08-04 | 2023-08-04 | 17, 21 | 2023-08-04 | 2023-08-04 | 0d | 2017-08-04 | 2017-08-04 | 0d |  |  |  |  |  |  |  |  |
| 23 | 1.6 | Schedule Margin |  | 8d | 2023-08-07 | 2023-08-16 | 22 | 2023-08-07 | 2023-08-14 | 6d |  |  | 0d |  |  |  |  |  |  |  |  |
| 24 | 1.7 | Contract Delivery | milestone | 0d | 2023-08-16 | 2023-08-16 | 23 | 2023-08-14 | 2023-08-14 | 0d |  |  | 0d |  |  |  |  |  |  |  |  |
